# etap 1

Schedule from MS Project, 2026-03-24 to 2027-04-07, status date 2026-12-01, costs in zł, A marks actual dates.
szkolenie

## Calendars

- Rosomak 260324: Mon-Fri 07:00-15:00; Sat-Sun off. Exceptions (off unless hours are given): 2026-12-24 to 2030-12-24 (24.12, recurring), 2026-12-25 to 2030-12-25 (25.12, recurring), 2026-12-26 to 2030-12-26 (26.12, recurring), 2026-12-31 to 2030-12-31 07:00-13:00 (31.12, recurring).

## Resources

| Resource | Unit | Rate | Cost per use |
| --- | --- | --- | --- |
| geolog | odwiert | 750 |  |
| studniarze | m | 200 | 3000 |
| geodeta |  |  | 700 |
| kb |  |  |  |
| dekarze |  |  |  |
| budowlańcy |  | 60 |  |

## Schedule

| ID | WBS | Task | Type | Duration | Start | Finish | Predecessors | Complete | Remaining | Baseline start | Baseline finish | Baseline duration | Baseline 1 start | Baseline 1 finish | Total slack | Constraint | Deadline | Resources | Work | Actual work | Cost | Baseline cost | Actual cost | Stare poprzedniki | Stare id |
| --- | --- | --- | --- | --- | --- | --- | --- | --- | --- | --- | --- | --- | --- | --- | --- | --- | --- | --- | --- | --- | --- | --- | --- | --- | --- |
| 1 | 1 | **Start** |  | 85.62d | 2026-03-24 A | 2026-07-21 A |  | 100% |  | 2026-03-24 | 2026-09-02 | 117d | 2026-03-24 | 2026-09-02 |  |  |  |  | 48h | 48h | 8,600 | 16,350 | 8,600 |  |  |
| 2 | 1.1 | Ogrodzenie placu budowy |  | 8d | 2026-03-24 A | 2026-04-02 A |  | 100% |  | 2026-03-24 | 2026-04-06 | 10d | 2026-03-24 | 2026-04-06 |  |  |  |  |  |  | 500 |  | 500 |  |  |
| 3 | 1.2 | Badanie gruntu |  | 1d | 2026-03-31 A | 2026-03-31 A | 2SS+5% | 100% |  | 2026-03-31 | 2026-03-31 | 1d | 2026-03-31 | 2026-03-31 |  |  |  | geolog [4 odwiert] |  |  | 3,000 | 2,250 | 3,000 | 2RR+50% |  |
| 4 | 1.3 | Uzyskanie pozwolenia na budowę |  | 69ed | 2026-04-07 A | 2026-06-15 A | 3FS+5d | 100% |  | 2026-04-07 | 2026-06-11 | 65ed | 2026-04-07 | 2026-06-11 |  |  | 2026-06-15 |  |  |  |  |  |  | 3ZR+5d |  |
| 5 | 1.4 | Budowa studni | inactive | 1d | 2026-04-08 | 2026-04-08 | 3FS+5d |  |  | 2026-04-08 | 2026-04-08 | 1d | 2026-04-08 | 2026-04-08 | 257d |  |  | studniarze [30 m] |  |  | 9,000 | 9,000 |  | 3ZR+5d |  |
| 6 | 1.5 | Zgłoszenie rozpoczęcia robót budowlanych | milestone | 0d | 2026-06-29 A | 2026-06-29 A | 4FS+14ed | 100% |  | 2026-06-25 | 2026-06-25 | 0d | 2026-06-25 | 2026-06-25 |  |  |  |  |  |  |  |  |  | 4ZR+14cd |  |
| 7 | 1.6 | **Przyłącza** |  | 18d | 2026-06-16 A | 2026-07-09 A |  | 100% |  | 2026-06-22 | 2026-09-01 | 52d | 2026-06-22 | 2026-09-01 |  |  |  |  |  |  | 4,400 | 4,400 | 4,400 |  |  |
| 8 | 1.6.1 | Wyk. przyłącza energetycznego |  | 4d | 2026-07-06 A | 2026-07-09 A |  | 100% |  | 2026-07-06 | 2026-07-09 | 4d | 2026-07-06 | 2026-07-09 |  | start no earlier than 2026-07-06 |  |  |  |  | 1,500 | 1,500 | 1,500 |  |  |
| 9 | 1.6.2 | Wyk. przyłącza kanalizacyjnego |  | 5d | 2026-06-16 A | 2026-06-22 A |  | 100% |  | 2026-06-22 | 2026-06-26 | 5d | 2026-06-22 | 2026-06-26 |  | start no earlier than 2026-06-22 |  |  |  |  | 1,100 | 1,100 | 1,100 |  |  |
| 10 | 1.6.3 | Wyk. przyłącza wodociągowego |  | 4d | 2026-06-29 A | 2026-07-02 A | 9 | 100% |  | 2026-06-29 | 2026-07-06 | 6d | 2026-06-29 | 2026-07-06 |  |  |  |  |  |  | 1,800 | 1,800 | 1,800 |  | 10 |
| 11 | 1.6.4 | ost. wyk. przyłączy | milestone | 0d | 2026-07-09 A | 2026-07-09 A | 8, 9, 10 | 100% |  | 2026-09-01 | 2026-09-01 | 0d | 2026-09-01 | 2026-09-01 |  | finish no earlier than 2026-09-01 |  |  |  |  |  |  |  | 8;9;10 | 11 |
| 12 | 1.7 | Geodezyjna inwentaryzacja powykonawcza |  | 1d | 2026-07-20 A | 2026-07-21 A | 11, 5, 7 | 100% |  | 2026-09-01 | 2026-09-02 | 1d | 2026-09-01 | 2026-09-02 |  |  |  | geodeta | 8h | 8h | 700 | 700 | 700 | 11;5;7 | 12 |
| 13 | 1.8 | Zatrudnienie kierownika budowy | milestone | 0d | 2026-06-15 A | 2026-06-15 A | 4 | 100% |  | 2026-06-11 | 2026-06-11 | 0d | 2026-06-11 | 2026-06-11 |  |  |  |  |  |  |  |  |  |  | 13 |
| 14 | 1.9 | Kontrola projektu |  | 5d | 2026-06-16 A | 2026-06-22 A | 13 | 100% |  | 2026-06-12 | 2026-06-18 | 5d | 2026-06-12 | 2026-06-18 |  |  |  | kb [50%] | 20h | 20h |  |  |  | 13 | 14 |
| 15 | 1.10 | Wykonanie kosztorysu inwestorskiego |  | 5d | 2026-06-16 A | 2026-06-22 A | 14SS | 100% |  | 2026-06-12 | 2026-06-18 | 5d | 2026-06-12 | 2026-06-18 |  |  |  | kb [50%] | 20h | 20h |  |  |  | 14RR | 15 |
| 16 | 2 | **Stan zero** |  | 5d | 2026-06-29 A | 2026-07-06 A |  | 100% |  | 2026-06-25 | 2026-07-01 | 4d | 2026-06-25 | 2026-07-01 |  |  |  |  | 56h | 56h | 3,820 | 3,580 | 3,820 |  | 16 |
| 17 | 2.1 | Wytyczenie budynku w terenie |  | 1d | 2026-06-29 A | 2026-06-30 A | 14, 6 | 100% |  | 2026-06-25 | 2026-06-26 | 1d | 2026-06-25 | 2026-06-26 |  |  |  | geodeta | 8h | 8h | 700 | 700 | 700 | 14;6 | 17 |
| 18 | 2.2 | **Fundament** |  | 4d | 2026-07-01 A | 2026-07-06 A |  | 100% |  | 2026-06-29 | 2026-07-01 | 3d | 2026-06-29 | 2026-07-01 |  |  |  |  | 48h | 48h | 3,120 | 2,880 | 3,120 |  | 18 |
| 19 | 2.2.1 | Rozprowadzenie kanalizacji pod podkładem |  | 1.5d | 2026-07-01 A | 2026-07-02 A | 17, 2 | 100% |  | 2026-06-29 | 2026-06-30 | 1.5d | 2026-06-29 | 2026-06-30 |  |  |  | budowlańcy [200%] | 24h | 24h | 1,560 | 1,440 | 1,560 | 17;2 | 19 |
| 20 | 2.2.2 | Izolacja części podziemnej |  | 0.5d | 2026-07-02 A | 2026-07-02 A | 19 | 100% |  | 2026-06-30 | 2026-06-30 | 0.5d | 2026-06-30 | 2026-06-30 |  |  |  | budowlańcy [200%] | 8h | 8h | 520 | 480 | 520 | 19 | 20 |
| 21 | 2.2.3 | Wylanie płyty betonowej |  | 8h | 2026-07-03 A | 2026-07-06 A | 20 | 100% |  | 2026-07-01 | 2026-07-01 | 1d | 2026-07-01 | 2026-07-01 |  |  |  | budowlańcy [200%] | 16h | 16h | 1,040 | 960 | 1,040 | 20 | 21 |
| 22 | 2.3 | Odbiór robót i wpisy w dzienniku budowy | milestone | 0d | 2026-07-06 A | 2026-07-06 A | 21 | 100% |  | 2026-07-01 | 2026-07-01 | 0d | 2026-07-01 | 2026-07-01 |  |  |  | kb |  |  |  |  |  | 21 | 22 |
| 23 | 3 | **Stan surowy otwarty** |  | 92d | 2026-07-30 A | 2026-12-04 |  | 94% | 5.63d | 2026-07-30 | 2026-11-13 | 77d | 2026-07-30 | 2026-11-13 | 0d |  |  |  | 768h | 768h | 129,920 | 127,520 | 84,920 |  | 23 |
| 24 | 3.1 | Murowanie ścian, kominów |  | 19d | 2026-07-30 A | 2026-10-09 A | 22, 21 | 100% |  | 2026-07-30 | 2026-09-02 | 25d | 2026-07-30 | 2026-09-02 |  |  |  | budowlańcy [400%] | 576h | 576h | 37,440 | 36,000 | 37,440 | 22;21 | 24 |
| 25 | 3.2 | Wykonanie wieńców, stropów, schodów |  | 6d | 2026-10-12 A | 2026-10-19 A | 24 | 100% |  | 2026-09-03 | 2026-09-14 | 8d | 2026-09-03 | 2026-09-14 |  | start no earlier than 2026-09-20 |  | budowlańcy [400%] | 192h | 192h | 12,480 | 11,520 | 12,480 | 24 | 25 |
| 26 | 3.3 | Zrobienie więźby |  | 10d | 2026-11-03 A | 2026-11-16 A | 25FS+14ed | 100% |  | 2026-10-13 | 2026-10-26 | 10d | 2026-10-13 | 2026-10-26 |  |  |  | dekarze [0.1%] |  |  | 35,000 | 35,000 | 35,000 | 25ZR+14cd | 26 |
| 27 | 3.4 | Kontrola i odbiór robót ulegających zakryciu | milestone | 0d | 2026-11-16 A | 2026-11-16 A | 26 | 100% |  | 2026-10-26 | 2026-10-26 | 0d | 2026-10-26 | 2026-10-26 |  |  |  | kb |  |  |  |  |  | 26 | 27 |
| 28 | 3.5 | Ułożenie pokrycia dachu |  | 14d | 2026-11-17 A | 2026-12-04 | 27 | 79% | 3d | 2026-10-27 | 2026-11-13 | 14d | 2026-10-27 | 2026-11-13 | 0d |  |  | dekarze [0.1%] |  |  | 45,000 | 45,000 |  | 27 | 28 |
| 29 | 3.6 | Odbiór robót i wpisy w dzienniku budowy | milestone | 0d | 2026-12-04 | 2026-12-04 | 28 |  |  | 2026-11-13 | 2026-11-13 | 0d | 2026-11-13 | 2026-11-13 | 0d |  |  | kb |  |  |  |  |  | 28 | 29 |
| 30 | 2.1.3 | Próby i odbiór instalacji |  | 1d | 2027-01-06 | 2027-01-07 | 11 |  |  |  |  |  |  |  | 0d |  |  |  | 16h |  | 520 |  |  |  |  |
| 31 | 3 | Zawiadomienie o zakończeniu budowy | milestone | 0d | 2027-04-07 | 2027-04-07 | 12 |  |  |  |  |  |  |  | 0d |  |  |  |  |  |  |  |  |  |  |
| 32 | 4 | nadzór budowy | manual | 209d | 2026-06-16 A | 2027-04-07 | 13 | 58% | 88d |  |  |  |  |  |  |  |  |  | 1672h | 968h | 6,270 |  | 3,630 |  |  |
| 33 | 2.2.1 | Budowa docelowego ogrodzenia |  | 15d | 2027-01-25 | 2027-02-15 | 29 |  |  |  |  |  |  |  | 5d |  |  |  | 240h |  | 15,600 |  |  |  |  |
| 34 | 2.1.1 | Montaż drzwi i okien |  | 1d | 2026-12-07 | 2026-12-07 | 29 |  |  |  |  |  |  |  | 0d |  |  |  | 32h |  | 2,080 |  |  |  |  |

Notes:
- 2: -2d - dodatkowa pomoc: +500zł
- 3: 2rr50% - słupki skrajne w połowie realizacji / +750 - dodatkowy odwiert
- 4: +5d - oprac. dok. geolog. / +7cd - 17.04.26 - uzupełnienie dok.
- 7: bufor czasowy
- 8: data rozpoczęcia?
- 9: data rozpoczęcia?
- 24: 30.07.26 skrócenie przerwy technolog. - usunięcie zwłoki / 21.09.26 - 4 budowlańców, -0,75d czasu trw.
- 26: skrócenie przerwy na wiązanie 28cd->14cd
