# etap 2

Schedule from MS Project, 2026-07-09 to 2027-04-07, status date 2026-12-01, costs in zł, A marks actual dates.
szkolenie

## Calendars

- Rosomak 260324: Mon-Fri 07:00-15:00; Sat-Sun off. Exceptions (off unless hours are given): 2026-12-24 to 2030-12-24 (24.12, recurring), 2026-12-25 to 2030-12-25 (25.12, recurring), 2026-12-26 to 2030-12-26 (26.12, recurring), 2026-12-31 to 2030-12-31 07:00-13:00 (31.12, recurring).

## Resources

| Resource | Unit | Rate |
| --- | --- | --- |
| kb |  |  |
| kominiarz | pkt | 150 |
| budowlańcy |  | 60 |

## Schedule

| ID | WBS | Task | Type | Duration | Start | Finish | Predecessors | Complete | Baseline start | Baseline finish | Baseline duration | Baseline 1 start | Baseline 1 finish | Total slack | Free slack | Constraint | Resources | Work | Cost | Baseline cost | Stare id | Stare poprzedniki |
| --- | --- | --- | --- | --- | --- | --- | --- | --- | --- | --- | --- | --- | --- | --- | --- | --- | --- | --- | --- | --- | --- | --- |
| 1 | 1 | **Instalacje i suche tynki** |  | 33d | 2026-12-07 | 2027-01-25 |  |  | 2026-11-16 | 2027-02-02 | 54d | 2026-11-16 | 2027-02-02 | 0d |  |  |  | 928h | 60,850 | 64,890 | 30 |  |
| 2 | 1.1 | Montaż drzwi i okien |  | 1d | 2026-12-07 | 2026-12-07 | 28 |  | 2026-11-16 | 2026-11-16 | 1d | 2026-11-16 | 2026-11-16 | 0d |  |  | budowlańcy [400%] | 32h | 2,080 | 1,920 | 31 | 29 |
| 3 | 1.2 | **Instalacje wewnętrzne (kanalizacja, woda, prąd, c.o.)** |  | 19d | 2026-12-08 | 2027-01-06 | 2 |  | 2026-11-17 | 2027-01-14 | 40d | 2026-11-17 | 2027-01-14 | 0d |  |  |  | 496h | 32,240 | 38,400 | 32 | 31 |
| 4 | 1.2.1 | wyk. inst. elek. |  | 12d | 2026-12-08 | 2026-12-23 | 2 |  |  |  |  |  |  | 7d |  |  | budowlańcy [200%] | 192h | 12,480 |  | 33 | 31 |
| 5 | 1.2.2 | wyk. inst. sanit. |  | 6d | 2026-12-08 | 2026-12-15 | 2 |  |  |  |  |  |  | 0d |  |  | budowlańcy [200%] | 96h | 6,240 |  | 34 | 31 |
| 6 | 1.2.3 | wyk. inst. w.u. |  | 5d | 2026-12-16 | 2026-12-22 | 5 |  |  |  |  |  |  | 0d |  |  | budowlańcy [200%] | 80h | 5,200 |  | 35 | 34 |
| 7 | 1.2.4 | wyk. inst. c.o. |  | 8d | 2026-12-23 | 2027-01-06 | 6 |  |  |  |  |  |  | 0d |  |  | budowlańcy [200%] | 128h | 8,320 |  | 36 | 35 |
| 8 | 1.3 | Próby i odbiór instalacji |  | 1d | 2027-01-06 | 2027-01-07 | 3, 7, 4, 29 |  | 2027-01-14 | 2027-01-15 | 1d | 2027-01-14 | 2027-01-15 | 0d |  |  | budowlańcy; kb | 16h | 520 | 480 | 37 | 32;11;36;33 |
| 9 | 1.4 | Sprawdzenie przewodów dym. i went. |  | 1d | 2026-12-08 | 2026-12-08 | 2 |  | 2026-11-17 | 2026-11-17 | 1d | 2026-11-17 | 2026-11-17 | 19d |  |  | kominiarz [7 pkt] |  | 1,050 | 1,050 | 38 | 31 |
| 10 | 1.5 | Wykonanie tynków i szlicht |  | 12d | 2027-01-07 | 2027-01-25 | 8, 9 |  | 2027-01-15 | 2027-02-02 | 12d | 2027-01-15 | 2027-02-02 | 0d |  |  | budowlańcy [400%] | 384h | 24,960 | 23,040 | 39 | 37;38 |
| 11 | 1.6 | Odbiór robót i wpisy w dzienniku budowy | milestone | 0d | 2027-01-25 | 2027-01-25 | 10 |  | 2027-02-02 | 2027-02-02 | 0d | 2027-02-02 | 2027-02-02 | 20d | 0d |  | kb |  |  |  | 40 | 39 |
| 12 | 2 | **Prace wykończeniowe i montażowe** |  | 52d | 2027-01-25 | 2027-04-07 |  |  | 2026-11-17 | 2027-03-29 | 92d | 2026-11-17 | 2027-03-29 | 0d |  |  |  | 1488h | 99,720 | 84,600 | 41 |  |
| 13 | 2.1 | Budowa docelowego ogrodzenia |  | 15d | 2027-01-25 | 2027-02-15 | 28 |  | 2026-11-17 | 2026-12-07 | 15d | 2026-11-17 | 2026-12-07 | 5d | 0d |  | budowlańcy [200%] | 240h | 15,600 | 14,400 | 42 | 29 |
| 14 | 2.2 | Montaż bramy |  | 1d | 2027-03-19 | 2027-03-22 | 13SS+28ed, 8 |  | 2027-02-02 | 2027-02-03 | 1d | 2027-02-02 | 2027-02-03 | 5d | 0d |  | budowlańcy [200%] | 16h | 1,040 | 960 | 43 | 42RR+28cd;37 |
| 15 | 2.3 | Przygotowanie ochrony budynku |  | 1d | 2027-03-22 | 2027-03-23 | 14 |  | 2027-02-03 | 2027-02-04 | 1d | 2027-02-03 | 2027-02-04 | 5d | 0d |  |  |  | 3,000 | 3,000 | 44 | 43 |
| 16 | 2.4 | Wykończenie elewacji |  | 5d | 2027-03-24 | 2027-03-31 | 15 |  | 2027-02-09 | 2027-02-16 | 5d | 2027-02-09 | 2027-02-16 | 5d |  |  | budowlańcy [400%] | 160h | 10,400 | 9,600 | 45 | 44 |
| 17 | 2.5 | **Prace wykończeniowe wewnątrz** |  | 52d | 2027-01-25 | 2027-04-07 |  |  | 2027-02-02 | 2027-03-29 | 39d | 2027-02-02 | 2027-03-29 | 0d |  |  |  | 1072h | 69,680 | 56,640 | 46 |  |
| 18 | 2.5.1 | Podłogi - wykończenie |  | 15d | 2027-02-25 | 2027-03-18 | 11, 10FS+28ed |  | 2027-03-02 | 2027-03-23 | 15d | 2027-03-02 | 2027-03-23 | 0d |  |  | budowlańcy [400%] | 480h | 31,200 | 28,800 | 47 | 40;39ZR+28cd |
| 19 | 2.5.2 | Wykończenie łazienek i biały montaż |  | 8d | 2027-02-15 | 2027-02-25 | 11, 10FS+14ed |  | 2027-02-16 | 2027-02-26 | 8d | 2027-02-16 | 2027-02-26 | 15d |  |  | budowlańcy [200%] | 128h | 8,320 | 7,680 | 48 | 40;39ZR+14cd |
| 20 | 2.5.3 | Wykończenie kuchni |  | 8d | 2027-02-08 | 2027-02-18 | 11, 10FS+14ed |  | 2027-02-16 | 2027-02-26 | 8d | 2027-02-16 | 2027-02-26 | 20d |  |  | budowlańcy [200%] | 128h | 8,320 | 7,680 | 49 | 40;39ZR+14cd |
| 21 | 2.5.4 | Ocieplenie i wykończenie poddasza |  | 5d | 2027-01-25 | 2027-02-01 | 11 |  | 2027-02-02 | 2027-02-09 | 5d | 2027-02-02 | 2027-02-09 | 33d |  |  | budowlańcy [200%] | 80h | 5,200 | 4,800 | 50 | 40 |
| 22 | 2.5.5 | Malowanie 1 |  | 1d | 2027-03-18 | 2027-03-19 | 18, 19, 20, 21 |  | 2027-03-23 | 2027-03-24 | 1d | 2027-03-23 | 2027-03-24 | 0d |  |  | budowlańcy [400%] | 32h | 2,080 | 1,920 | 51 | 47;48;49;50 |
| 23 | 2.5.6 | Malowanie 2 |  | 1d | 2027-03-22 | 2027-03-23 | 22 |  | 2027-03-24 | 2027-03-25 | 1d | 2027-03-24 | 2027-03-25 | 0d |  |  | budowlańcy [400%] | 32h | 2,080 | 1,920 | 52 | 51 |
| 24 | 2.5.7 | Montaż drzwi wewnętrznych |  | 1d | 2027-03-23 | 2027-03-24 | 23 |  | 2027-03-25 | 2027-03-26 | 1d | 2027-03-25 | 2027-03-26 | 0d |  |  | budowlańcy [200%] | 16h | 1,040 | 960 | 53 | 52 |
| 25 | 2.5.8 | Montaż urządzeń grzewczych |  | 1d | 2027-03-23 | 2027-03-24 | 23 |  | 2027-03-25 | 2027-03-26 | 1d | 2027-03-25 | 2027-03-26 | 0d |  |  | budowlańcy [200%] | 16h | 1,040 | 960 | 54 | 52 |
| 26 | 2.5.9 | Malowanie 3 |  | 5d | 2027-03-31 | 2027-04-07 | 24, 25 |  | 2027-03-26 | 2027-03-29 | 1d | 2027-03-26 | 2027-03-29 | 0d |  |  | budowlańcy [400%] | 160h | 10,400 | 1,920 | 55 | 53;54 |
| 27 | 2.6 | Odbiór robót i wpisy w dzienniku budowy | milestone | 0d | 2027-04-07 | 2027-04-07 | 26, 16 |  | 2027-03-29 | 2027-03-29 | 0d | 2027-03-29 | 2027-03-29 | 0d |  |  | kb |  |  |  | 56 | 55;45 |
| 28 | 1.3.6 | Odbiór robót i wpisy w dzienniku budowy | milestone | 0d | 2026-12-04 | 2026-12-04 |  |  |  |  |  |  |  | 0d |  |  |  |  |  |  |  |  |
| 29 | 1.1.6.4 | ost. wyk. przyłączy | milestone | 0d | 2026-07-09 A | 2026-07-09 A |  | 100% |  |  |  |  |  |  |  | finish no earlier than 2026-09-01 |  |  |  |  |  |  |
| 30 | 3 | Zawiadomienie o zakończeniu budowy | milestone | 0d | 2027-04-07 | 2027-04-07 | 27 |  |  |  |  |  |  | 0d |  |  |  |  |  |  |  |  |

Notes:
- 8: przyłącza wykonane?
- 22: trzykrotne?
